# 6046 Project Schedule as of 15 Apri l04.doc

Schedule from MS Project, 2004-08-23 to 2004-11-24, A marks actual dates.

## Calendars

- Standard: Mon-Fri 08:00-12:00, 13:00-17:00; Sat-Sun off.

## Resources

| Resource |
| --- |
| JM |
| MD |
| MF |
| WA |
| LA |
| SW |
| SQC |

## Schedule

| ID | WBS | Task | Duration | Start | Finish | Predecessors | Complete | Remaining | Baseline start | Baseline finish | Baseline duration | Total slack | Constraint | Resources | Work | Actual work |
| --- | --- | --- | --- | --- | --- | --- | --- | --- | --- | --- | --- | --- | --- | --- | --- | --- |
| 2 | 1 | **General Project** | 59.38d | 2004-08-23 08:00 A | 2004-11-12 11:02 A |  | 100% |  | 2004-08-23 08:00 | 2004-08-25 17:00 | 3d |  |  |  | 22h | 22h |
| 3 | 1.1 | Review JAMSTEC requirements, bug lists, code status and misc. info | 10h | 2004-08-23 08:00 A | 2004-08-24 10:00 A |  | 100% |  | 2004-08-23 08:00 | 2004-08-24 10:00 | 10h |  |  | WA | 10h | 10h |
| 4 | 1.2 | Estimation and schedule rework | 4h | 2004-08-24 08:00 A | 2004-08-24 12:00 A | 3 | 100% |  | 2004-08-24 08:00 | 2004-08-24 12:00 | 4h |  |  | WA | 4h | 4h |
| 5 | 1.3 | Rework following review | 2h | 2004-08-25 08:00 A | 2004-08-25 10:00 A | 4 | 100% |  | 2004-08-25 08:00 | 2004-08-25 10:00 | 2h |  | start no earlier than 2004-08-25 08:00 | WA | 2h | 2h |
| 6 | 1.4 | DVU and PLC SRS Update | 3h | 2004-08-25 10:00 A | 2004-08-25 14:00 A | 5 | 100% |  | 2004-08-25 10:00 | 2004-08-25 14:00 | 3h |  |  | WA | 3h | 3h |
| 7 | 1.5 | Review | 1h | 2004-08-25 14:00 A | 2004-08-25 15:00 A | 6 | 100% |  | 2004-08-25 14:00 | 2004-08-25 15:00 | 1h |  |  | LA | 1h | 1h |
| 8 | 1.6 | Rework | 2h | 2004-11-11 08:26 A | 2004-11-12 11:02 A | 7 | 100% |  | 2004-08-25 15:00 | 2004-08-25 17:00 | 2h |  |  | WA | 2h | 2h |
| 9 | 2 | **Payload Controller (PLC)** | 67.13d | 2004-08-23 08:00 A | 2004-11-24 09:02 |  | 97% | 1.81d | 2004-08-26 08:00 | 2004-09-29 11:00 | 24.38d | 0.5d |  |  | 335h | 326.12h |
| 10 | 2.1 | **Development** | 67.13d | 2004-08-23 08:00 A | 2004-11-24 09:02 |  | 97% | 1.81d | 2004-08-26 08:00 | 2004-09-29 11:00 | 24.38d | 0.5d |  |  | 335h | 326.12h |
| 11 | 2.1.1 | **7k Sonar Related** | 9.25d | 2004-08-23 08:00 A | 2004-09-03 10:00 A |  | 100% |  | 2004-08-26 08:00 | 2004-09-03 10:00 | 6.25d |  |  |  | 41h | 41h |
| 12 | 2.1.1.1 | Altitude collection and subscription from sonar | 3h | 2004-08-26 08:00 A | 2004-08-26 11:00 A | 8 | 100% |  | 2004-08-26 08:00 | 2004-08-26 11:00 | 3h |  |  | WA | 3h | 3h |
| 13 | 2.1.1.2 | 7K SONAR integration: Generic PLC commands (SendCommand() etc.) | 2h | 2004-08-26 11:00 A | 2004-08-26 14:00 A | 12 | 100% |  | 2004-08-26 11:00 | 2004-08-26 14:00 | 2h |  |  | WA | 2h | 2h |
| 14 | 2.1.1.3 | 7K SONAR integration: Store and restore configuration | 1h | 2004-08-26 14:00 A | 2004-08-26 15:00 A | 13 | 100% |  | 2004-08-26 14:00 | 2004-08-26 15:00 | 1h |  |  | WA | 1h | 1h |
| 15 | 2.1.1.4 | 7K SONAR integration: Rework 7k internal error handling and reporting | 4h | 2004-08-26 15:00 A | 2004-08-27 10:00 A | 14 | 100% |  | 2004-08-26 15:00 | 2004-08-27 10:00 | 4h |  |  | WA | 4h | 4h |
| 16 | 2.1.1.5 | 7K SONAR integration: Health and status reporting | 4h | 2004-08-27 10:00 A | 2004-08-27 15:00 A | 15 | 100% |  | 2004-08-27 10:00 | 2004-08-27 15:00 | 4h |  |  | WA | 4h | 4h |
| 17 | 2.1.1.6 | Optional collection of 7k attitude data from sonar (e.g., MBARI etc) | 4h | 2004-08-27 15:00 A | 2004-08-30 10:00 A | 16 | 100% |  | 2004-08-27 15:00 | 2004-08-30 10:00 | 4h |  |  | WA | 4h | 4h |
| 18 | 2.1.1.7 | Client messaging support in DLL interface etc. | 11h | 2004-08-30 10:00 A | 2004-08-31 14:00 A | 17 | 100% |  | 2004-08-30 10:00 | 2004-08-31 14:00 | 11h |  |  | WA | 11h | 11h |
| 19 | 2.1.1.8 | Handle remaining messages from sonar | 4h | 2004-09-02 15:00 A | 2004-09-03 10:00 A | 18 | 100% |  | 2004-09-02 15:00 | 2004-09-03 10:00 | 4h |  |  | WA | 4h | 4h |
| 20 | 2.1.1.9 | Extend 7k commands to fully support 7k panel in DVU | 8h | 2004-08-23 08:00 A | 2004-08-23 17:00 A |  | 100% |  |  |  |  |  |  | WA | 8h | 8h |
| 21 | 2.1.2 | **JAMSTEC, SBUS (AUV62) Requirements** | 18.71d | 2004-09-08 13:00 A | 2004-10-05 09:39 |  | 94% | 1.15d | 2004-09-08 13:00 | 2004-09-13 11:00 | 2.88d | 36.42d |  |  | 39h | 37h |
| 22 | 2.1.2.1 | TCP/IP support & enhancements | 17.64h | 2004-09-08 13:00 A | 2004-10-01 11:53 A |  | 100% |  | 2004-09-08 13:00 | 2004-09-10 12:00 | 16h |  |  | WA [136%] | 24h | 24h |
| 23 | 2.1.2.2 | Ack/nak of routed commands to 7k sonar and command to suport non-specific addressing | 7h | 2004-09-10 13:00 A | 2004-09-13 11:00 A | 22 | 100% |  | 2004-09-10 13:00 | 2004-09-13 11:00 | 7h |  |  | WA | 7h | 7h |
| 24 | 2.1.2.3 | Test Generic 7k sensor with TCP input | 8h | 2004-10-04 09:39 A | 2004-10-05 09:39 | 23 | 75% | 2h |  |  |  | 36.42d |  | WA | 8h | 6h |
| 25 | 2.1.3 | **Developer Testing, Debugging, Optimization and Miscellaneous** | 40.68d | 2004-09-13 11:00 A | 2004-11-09 08:26 |  | 97% | 1.36d | 2004-09-13 11:00 | 2004-09-21 09:00 | 5.75d | 11.57d |  |  | 206h | 199.12h |
| 26 | 2.1.3.1 | Investigate failure of latest 7kCenter with PLC | 2h | 2004-09-13 11:00 A | 2004-09-13 14:00 A | 24 | 100% |  | 2004-09-13 11:00 | 2004-09-13 14:00 | 2h |  |  | WA | 2h | 2h |
| 27 | 2.1.3.2 | Enhance network robustness in PLC interface DLL | 8h | 2004-09-13 14:00 A | 2004-09-14 14:00 A | 26 | 100% |  | 2004-09-13 14:00 | 2004-09-14 14:00 | 8h |  |  | WA | 8h | 8h |
| 28 | 2.1.3.3 | Correct known defects per DevTrack (issues as of 15 November 04) | 172h | 2004-09-14 14:00 A | 2004-11-09 08:26 | 27 | 96% | 6.88h | 2004-09-14 14:00 | 2004-09-20 11:00 | 30h | 11.57d |  | WA | 172h | 165.12h |
| 29 | 2.1.3.4 | General testing and debugging | 24h | 2004-09-20 11:00 A | 2004-09-28 11:24 A | 28 | 100% |  | 2004-09-20 11:00 | 2004-09-21 09:00 | 6h |  |  | WA | 24h | 24h |

Notes:
- 26: Bug identified in 7kCenter. Queries in w/ Pam and resolution pending.

| ID | WBS | Task | Duration | Start | Finish | Predecessors | Complete | Remaining | Baseline start | Baseline finish | Baseline duration | Total slack | Free slack | Constraint | Resources | Work | Actual work |
| --- | --- | --- | --- | --- | --- | --- | --- | --- | --- | --- | --- | --- | --- | --- | --- | --- | --- |
| 30 | 2.1.4 | **Miscellaneous** | 67.13d | 2004-08-23 08:00 A | 2004-11-24 09:02 A |  | 100% |  | 2004-09-21 09:00 | 2004-09-29 11:00 | 6.25d |  |  |  |  | 49h | 49h |
| 31 | 2.1.4.1 | Update installation script and testing | 16h | 2004-09-28 11:24 A | 2004-09-30 11:24 A | 29 | 100% |  | 2004-09-28 11:00 | 2004-09-28 16:00 | 4h |  |  |  | WA | 16h | 16h |
| 32 | 2.1.4.2 | Developer testing and debugging | 16h | 2004-09-29 09:24 A | 2004-10-07 14:15 A | 31 | 100% |  | 2004-09-28 16:00 | 2004-09-29 11:00 | 4h |  |  |  | WA | 16h | 16h |
| 33 | 2.1.4.3 | Installation script updates including user interface standardization | 6h | 2004-11-12 11:02 A | 2004-11-15 14:02 A |  | 100% |  |  |  |  |  |  |  | WA | 6h | 6h |
| 34 | 2.1.4.4 | SQC support | 4h | 2004-08-23 08:00 A | 2004-08-23 12:00 A |  | 100% |  |  |  |  |  |  |  | WA | 4h | 4h |
| 35 | 2.1.4.5 | Configuration management | 3h | 2004-11-23 15:02 A | 2004-11-24 09:02 A |  | 100% |  |  |  |  |  |  |  | WA | 3h | 3h |
| 36 | 2.1.4.6 | Rework 7k outbound memory module to improve robustness | 4h | 2004-11-23 10:02 A | 2004-11-23 15:02 A |  | 100% |  |  |  |  |  |  |  | WA | 4h | 4h |
| 37 | 3 | **Data Visualization Utility (DVU)** | 64.19d | 2004-08-23 08:00 A | 2004-11-19 09:29 |  | 76% | 15.72d | 2004-08-23 08:00 | 2004-09-23 11:46 | 23.47d | 3.44d |  |  |  | 171h | 126.65h |
| 38 | 3.1 | **Bathy Display** | 14d | 2004-08-23 08:00 A | 2004-09-09 17:00 |  | 97% | 0.45d |  |  |  | 53.63d |  |  |  | 39h | 37.8h |
| 39 | 3.1.1 | Color Palettes | 8h | 2004-09-07 08:00 A | 2004-09-07 17:00 A |  | 100% |  |  |  |  |  |  | start no earlier than 2004-09-07 08:00 | JM | 8h | 8h |
| 40 | 3.1.2 | Min and Max depth Information | 8h | 2004-09-09 08:00 A | 2004-09-09 17:00 A | 39 | 100% |  |  |  |  |  |  | start no earlier than 2004-09-09 08:00 | JM | 8h | 8h |
| 41 | 3.1.3 | 2D Bathy scrolling display | 8.89h | 2004-08-23 08:00 A | 2004-09-01 15:02 |  | 85% | 1.33h | 2004-08-23 08:00 | 2004-08-24 08:53 | 8.89h | 59.87d |  |  | JM [90%] | 8h | 6.8h |
| 42 | 3.1.4 | Extras: user defined scaling & palette scaling | 16.67h | 2004-08-23 08:00 A | 2004-08-25 08:40 A |  | 100% |  |  |  |  |  |  |  | JM [90%] | 15h | 15h |
| 43 | 3.2 | 7k sonar control panel | 4.45h | 2004-08-24 08:53 A | 2004-08-24 14:20 A | 41 | 100% |  | 2004-08-24 08:53 | 2004-08-24 14:20 | 4.45h |  |  |  | JM [90%] | 4h | 4h |
| 44 | 3.3 | Configuration and Real Time Settings overhaul for 7K System | 21.11h | 2004-08-24 14:20 A | 2004-09-01 09:48 A | 43 | 100% |  | 2004-08-24 14:20 | 2004-08-27 10:26 | 21.11h |  |  |  | JM [90%] | 19h | 19h |
| 45 | 3.4 | Config file handling | 8.89h | 2004-08-27 08:00 A | 2004-08-30 08:53 A | 40, 44 | 100% |  | 2004-09-10 14:46 | 2004-09-13 15:40 | 8.89h |  |  |  | JM [90%] | 8h | 8h |
| 46 | 3.5 | Client synchronization issues | 8.89h | 2004-09-13 08:00 A | 2004-09-14 08:53 |  | 90% | 0.89h | 2004-09-13 15:40 | 2004-09-14 16:33 | 8.89h | 51.41d | 0.51d | start no earlier than 2004-09-13 08:00 | JM [90%] | 8h | 7.2h |
| 47 | 3.6 | Network Error Handling/Testing (pending Wayne's update) | 16.67h | 2004-09-14 14:00 A | 2004-09-16 14:40 | 46, 27 | 95% | 0.83h | 2004-09-14 16:33 | 2004-09-17 08:13 | 16.67h | 48.92d |  | start no earlier than 2004-09-13 08:00 | JM [90%] | 15h | 14.25h |
| 48 | 3.8 | Correct known defects per DevTrack (issues as of 31 Aug 04) | 17.78h | 2004-08-30 08:00 A | 2004-09-01 09:46 A | 45 | 100% |  | 2004-09-17 08:13 | 2004-09-21 10:00 | 17.78h |  |  |  | JM [90%] | 16h | 16h |
| 49 | 3.9 | Testing and Debugging | 17.78h | 2004-09-02 08:00 A | 2004-09-06 09:46 | 48 | 90% | 1.78h | 2004-09-21 10:00 | 2004-09-23 11:46 | 17.78h | 57.41d |  |  | JM [90%] | 16h | 14.4h |
| 50 | 3.10 | Add wedge display | 6h | 2004-09-06 09:46 A | 2004-09-06 16:46 A | 49 | 100% |  |  |  |  |  |  |  | JM | 6h | 6h |
| 51 | 3.13 | **Enhanced Development (Phase III - NOT Part of Phase II Scope)** | 9.19d | 2004-11-08 08:00 | 2004-11-19 09:29 |  |  |  |  |  |  | 3d |  |  |  | 40h |  |
| 52 | 3.13.1 | Mesh Surface Mode | 16h | 2004-11-08 08:00 | 2004-11-09 17:00 |  |  |  |  |  |  | 3d | 0d | start no earlier than 2004-11-08 08:00 | JM | 16h |  |
| 53 | 3.13.2 | 3D Movement with the Mouse | 8h | 2004-11-16 09:29 | 2004-11-17 09:29 | 52 |  |  |  |  |  | 3.44d | 0d |  | JM | 8h |  |
| 54 | 3.13.3 | Scrolling History Display | 16h | 2004-11-17 09:29 | 2004-11-19 09:29 | 53 |  |  |  |  |  | 3.44d |  |  | JM | 16h |  |

Notes:
- 39: Color Palettes that adjust to the min and max depth in real time and set the points color appropriately in the scrolling history.
- 40: Current Min and Max Depth information as colored points as well as hovering test info, or moving mabels on the depth axis or any combination
- 44: Need real XML Data
- 52: connect the dots to form a mesh-like surface of connected points
- 53: Ability to move around in 3D using the mouse+Right-Click functionality of common 3D Displays
- 54: Peer Review with Field Support and Signal Processing on the scrolling display possibilities

| ID | WBS | Task | Type | Duration | Start | Finish | Predecessors | Complete | Remaining | Baseline start | Baseline finish | Baseline duration | Total slack | Free slack | Constraint | Resources | Work | Actual work |
| --- | --- | --- | --- | --- | --- | --- | --- | --- | --- | --- | --- | --- | --- | --- | --- | --- | --- | --- |
| 55 | 4 | **User Manual** |  | 23.97d | 2004-10-07 14:15 A | 2004-11-10 14:01 A |  | 100% |  | 2004-09-29 11:00 | 2004-10-19 09:30 | 13.81d |  |  |  |  | 66h | 66h |
| 56 | 4.1 | Collect and issue technical info for manual update |  | 11.11h | 2004-10-07 14:15 A | 2004-10-22 13:08 A | 32 | 100% |  | 2004-09-29 11:00 | 2004-09-30 11:53 | 8.89h |  |  |  | WA [90%] | 10h | 10h |
| 57 | 4.2 | Feature Completion |  | 80h | 2004-10-22 13:08 A | 2004-11-05 13:08 A | 56 | 100% |  | 2004-09-30 11:53 | 2004-10-14 11:53 | 80h |  |  |  | MD [50%] | 40h | 40h |
| 58 | 4.3 | Review |  | 8.89h | 2004-11-05 13:08 A | 2004-11-08 14:01 A | 57 | 100% |  | 2004-10-14 11:53 | 2004-10-15 09:30 | 5.63h |  |  |  | WA [90%] | 8h | 8h |
| 59 | 4.4 | Rework |  | 16h | 2004-11-08 14:01 A | 2004-11-10 14:01 A | 58 | 100% |  | 2004-10-15 09:30 | 2004-10-19 09:30 | 16h |  |  |  | MD [50%] | 8h | 8h |
| 60 | 4.5 | Manual completion | milestone | 0h | 2004-11-10 14:01 A | 2004-11-10 14:01 A | 59 | 100% |  | 2004-10-19 09:30 | 2004-10-19 09:30 | 0h |  |  |  |  |  |  |
| 61 | 5 | **Systems integration testing & rework** |  | 11d | 2004-10-12 08:00 A | 2004-10-26 17:00 |  | 45% | 6d | 2004-08-25 14:00 | 2004-10-18 11:00 | 37.75d | 3.69d |  |  |  | 88h | 40h |
| 62 | 5.1 | Systems integration testing & rework |  | 25h | 2004-10-12 08:00 A | 2004-10-15 09:00 A | 49 | 100% |  | 2004-09-29 11:00 | 2004-10-04 12:00 | 25h |  |  | start no earlier than 2004-10-12 08:00 | SW | 25h | 25h |
| 63 | 5.2 | Rework |  | 15h | 2004-10-15 09:00 A | 2004-10-18 17:00 A | 62 | 100% |  | 2004-10-06 13:00 | 2004-10-08 11:00 | 15h |  |  |  | SW | 15h | 15h |
| 64 | 5.3 | Formal Testing |  | 24h | 2004-10-19 08:00 | 2004-10-21 17:00 | 63 |  |  | 2004-10-08 11:00 | 2004-10-13 11:00 | 24h | 3.69d | 0d |  | LA | 24h |  |
| 65 | 5.4 | Rework |  | 10h | 2004-10-22 08:00 | 2004-10-25 10:00 | 64 |  |  | 2004-10-13 11:00 | 2004-10-14 14:00 | 10h | 3.69d | 0d |  | SW | 10h |  |
| 66 | 5.5 | Sea-trials and/or tank testing |  | 14h | 2004-10-25 10:00 | 2004-10-26 17:00 | 65 |  |  | 2004-10-14 14:00 | 2004-10-18 11:00 | 14h | 3.69d | 0d |  | SW | 14h |  |
| 67 | 6 | **6046 Release** |  | 0.5d | 2004-08-23 08:00 | 2004-08-23 12:00 |  |  |  | 2004-10-18 11:00 | 2004-10-18 16:00 | 0.5d | 67.13d |  |  |  | 4h |  |
| 68 | 6.1 | CD Preparation |  | 2h | 2004-08-23 08:00 | 2004-08-23 10:00 |  |  |  | 2004-10-18 11:00 | 2004-10-18 14:00 | 2h | 67.13d | 0d |  | MF | 2h |  |
| 69 | 6.2 | CD Installation testing |  | 2h | 2004-08-23 10:00 | 2004-08-23 12:00 | 68 |  |  | 2004-10-18 14:00 | 2004-10-18 16:00 | 2h | 67.13d | 0d |  | MF | 2h |  |
| 70 | 6.3 | Release | milestone | 0h | 2004-08-23 12:00 | 2004-08-23 12:00 | 69 |  |  | 2004-10-18 16:00 | 2004-10-18 16:00 | 0h | 67.13d |  |  |  |  |  |
| 71 | 8 | **Thales/Fugro & NCSC Requirements** |  | 63.63d | 2004-08-24 12:30 A | 2004-11-22 09:02 |  | 9% | 58.21d | 2004-10-18 11:00 | 2004-10-26 09:00 | 5.75d | 2.5d |  |  |  | 132h | 12h |
| 72 | 8.1 | RESON 7k sonar trigger control panel and setup (DVU) |  | 88.89h | 2004-10-27 08:00 | 2004-11-16 09:29 | 66 |  |  |  |  |  | 3.69d | 0d |  | JM [90%] | 80h |  |
| 73 | 8.2 | **Time Synchonization** |  | 4.25d | 2004-11-15 16:02 A | 2004-11-22 09:02 | 72 | 35% | 2.75d |  |  |  | 2.5d |  |  |  | 34h | 12h |
| 74 | 8.2.1 | Complete TimeSync DLL and test |  | 24h | 2004-11-15 16:02 A | 2004-11-18 16:02 |  | 50% | 12h | 2004-09-03 10:00 | 2004-09-07 10:00 | 16h | 2.5d | 0d |  | WA | 24h | 12h |
| 75 | 8.2.2 | Time synchronization: Standalone mode, slaved mode and sync of timer to 7k time (using TimeSyncDLL) |  | 2h | 2004-11-18 16:02 | 2004-11-19 09:02 | 74 |  |  | 2004-09-07 10:00 | 2004-09-07 12:00 | 2h | 2.5d | 0d |  | WA | 2h |  |
| 76 | 8.2.3 | Slave TimeSync DLL to 7k time driver when available |  | 8h | 2004-11-19 09:02 | 2004-11-22 09:02 | 75 |  |  | 2004-09-07 13:00 | 2004-09-08 12:00 | 8h | 2.5d |  |  | WA | 8h |  |
| 77 | 8.3 | EdgeTech FSDW to subscribe to critical trigger parameters |  | 4h | 2004-08-24 12:30 | 2004-08-24 16:30 |  |  |  | 2004-10-21 16:00 | 2004-10-22 11:00 | 4h | 7.5d | 0d |  | WA | 4h |  |
| 78 | 8.4 | EdgeTech SONAR integration: EdgeTech Trigger notification and range selection |  | 8h | 2004-08-24 16:30 | 2004-09-01 17:00 | 77 |  |  | 2004-10-22 11:00 | 2004-10-25 11:00 | 8h | 7.56d | 0d |  | WA | 8h |  |
| 79 | 8.5 | EdgeTech SONAR integration: EdgeTech to use external uncoupled triggering |  | 2h | 2004-09-02 08:00 | 2004-09-02 10:00 | 78 |  |  | 2004-10-25 11:00 | 2004-10-25 14:00 | 2h | 7.75d | 0d |  | WA | 2h |  |
| 80 | 8.6 | Developer testing |  | 4h | 2004-11-12 14:29 | 2004-11-15 09:29 | 79 |  |  | 2004-10-25 14:00 | 2004-10-26 09:00 | 4h | 7.44d |  |  | WA | 4h |  |

| ID | WBS | Task | Duration | Start | Finish | Predecessors | Complete | Remaining | Baseline start | Baseline finish | Baseline duration | Total slack | Free slack | Constraint | Resources | Work | Actual work |
| --- | --- | --- | --- | --- | --- | --- | --- | --- | --- | --- | --- | --- | --- | --- | --- | --- | --- |
| 81 | 9 | **Testing and Release** | 30.03d | 2004-09-27 08:00 | 2004-11-08 08:13 |  |  |  | 2004-10-26 09:00 | 2004-10-29 09:00 | 3d | 12.6d |  |  |  | 92h |  |
| 82 | 9.1 | Update STP based on revised PLC SRS | 8h | 2004-09-27 08:00 | 2004-09-27 17:00 |  |  |  |  |  |  | 13.6d | 0d | start no earlier than 2004-09-27 08:00 | LA | 8h |  |
| 83 | 9.2 | SQC Fault Model Testing | 32h | 2004-09-28 08:00 | 2004-10-01 17:00 | 82 |  |  | 2004-10-04 13:00 | 2004-10-06 12:00 | 16h | 13.6d | 0d |  | LA | 32h |  |
| 84 | 9.3 | Rework | 28.74h | 2004-10-04 08:00 | 2004-11-03 13:13 | 83 |  |  | 2004-10-28 09:00 | 2004-10-28 14:00 | 4h | 12.6d | 0d |  | WA; JM | 32h |  |
| 85 | 9.4 | SQC formal testing | 16h | 2004-11-03 13:13 | 2004-11-05 13:13 | 84 |  |  | 2004-10-26 09:00 | 2004-10-28 09:00 | 16h | 12.6d | 0d |  | LA | 16h |  |
| 86 | 9.5 | CD Preparation | 2h | 2004-11-05 13:13 | 2004-11-05 15:13 | 85 |  |  | 2004-10-28 14:00 | 2004-10-28 16:00 | 2h | 12.6d | 0d |  | MF | 2h |  |
| 87 | 9.6 | CD installation testing | 2h | 2004-11-05 15:13 | 2004-11-08 08:13 | 86 |  |  | 2004-10-28 16:00 | 2004-10-29 09:00 | 2h | 12.6d |  |  | MF | 2h |  |
| 88 | 11 | **Miscellaneous post MBARI/JAMSTEC** | 67.63d? | 2004-08-23 08:00 A | 2004-11-24 14:02 |  | 2% | 66.45d? | 2004-10-28 14:00 | 2004-11-01 14:00 | 2d | 0d |  |  |  | 107h | 2h |
| 89 | 11.1 | Change default registry setting destination & support backwards compatibility | 6h | 2004-11-15 14:02 | 2004-11-22 14:02 |  |  |  | 2004-09-21 09:00 | 2004-09-21 11:00 | 2h | 2d |  |  | WA | 6h |  |
| 90 | 11.2 | Trigger controller/I/O module | 28h | 2004-10-05 09:39 | 2004-10-22 13:49 |  |  |  |  |  |  | 23.03d |  |  | WA | 28h |  |
| 91 | 11.3 | **Critical parameter handling** | 61.01d | 2004-08-31 14:00 A | 2004-11-24 14:02 |  | 17% | 50.84d |  |  |  | 0d |  |  |  | 12h | 2h |
| 92 | 11.3.1 | Critical parameter subscription control mechanism | 8h | 2004-08-31 14:00 A | 2004-09-01 14:00 |  | 25% | 6h | 2004-08-31 14:00 | 2004-09-01 14:00 | 8h | 60.01d |  |  | WA | 8h | 2h |
| 93 | 11.3.2 | Critical parameter data table: Sound speed, trigger parameters & vehicle attitude | 4h | 2004-11-24 09:02 | 2004-11-24 14:02 |  |  |  | 2004-09-01 14:00 | 2004-09-02 09:00 | 4h | 0d |  |  | WA | 4h |  |
| 94 | 11.4 | Preprocessing of routed 7k messages prior to dispatch | 5h | 2004-11-22 14:02 | 2004-11-23 10:02 |  |  |  | 2004-09-02 09:00 | 2004-09-02 15:00 | 5h | 1.38d |  |  | WA | 5h |  |
| 95 | 11.5 | Dongle replacement (once known) | 40h | 2004-09-02 10:00 | 2004-10-04 09:39 |  |  |  |  |  |  | 37.42d |  |  | WA | 40h |  |
| 96 | 11.6 | Time Sync DLL Enhancements | 16h | 2004-11-09 08:26 | 2004-11-11 08:26 |  |  |  | 2004-10-28 14:00 | 2004-11-01 14:00 | 16h | 9.57d |  | start no earlier than 2004-10-28 08:00 | WA | 16h |  |
| 98 | 11.7 | CRC Requirements -- TODO: UNDER CONSTRUCTION | 8h? | 2004-08-23 08:00 | 2004-08-23 17:00 |  |  |  |  |  |  | 66.63d |  |  |  |  |  |

Notes:
- 90: Trigger controller still largely unknown. Existing code is disabled in current PLC but re-work will be likely once more is known
- 96: Place holder as this work is to move into the architecture project planning in due course. Break down as follows: / ·create new COM-based service framework; / ·repackage internals; and / ·create install scrip for service.
