# 6046 Phase II project schedule -- 7k Release

Schedule from MS Project, 2003-10-27 to 2004-04-08.

## Calendars

- Standard: Mon-Fri 08:00-12:00, 13:00-17:00; Sat-Sun off.

## Resources

| Resource |
| --- |
| WA |
| JM |
| MF |
| MD |
| WAWA |

## Schedule

| ID | WBS | Task | Type | Duration | Start | Finish | Predecessors | Baseline start | Baseline finish | Baseline duration | Total slack | Free slack | Constraint | Resources | Work |
| --- | --- | --- | --- | --- | --- | --- | --- | --- | --- | --- | --- | --- | --- | --- | --- |
| 2 | 1 | **Dependencies** |  | 20d | 2003-10-27 | 2003-11-24 |  | 2003-10-27 | 2003-11-24 | 20d | 0d |  |  |  |  |
| 4 | 1.1 | Jon Marcus available | milestone | 0h | 2003-11-17 | 2003-11-17 |  | 2003-11-17 | 2003-11-17 | 0h | 0d |  | must start on 2003-11-17 |  |  |
| 5 | 1.2 | Mindy Ferguson available | milestone | 0h | 2003-10-27 | 2003-10-27 |  | 2003-10-27 | 2003-10-27 | 0h | 118.93d |  |  |  |  |
| 6 | 1.3 | Wayne Arcus available | milestone | 0h | 2003-10-27 | 2003-10-27 |  | 2003-10-27 | 2003-10-27 | 0h | 0d |  | start no earlier than 2003-10-27 |  |  |
| 7 | 1.4 | Marlene Doyle available | milestone | 0h | 2003-10-27 | 2003-10-27 |  | 2003-10-27 | 2003-10-27 | 0h | 102.26d | 62.14d |  |  |  |
| 8 | 1.5 | 7k software and hardware completion | milestone | 0h | 2003-10-27 | 2003-10-27 |  | 2003-10-27 | 2003-10-27 | 0h | 118.93d |  |  |  |  |
| 9 | 1.6 | Receive MBARI VC simulator | milestone | 0h | 2003-10-27 | 2003-10-27 |  | 2003-10-27 | 2003-10-27 | 0h | 118.93d |  |  |  |  |
| 10 | 1.7 | Wayne Arcus in Goleta | milestone | 0h | 2003-11-24 | 2003-11-24 |  | 2003-11-24 | 2003-11-24 | 0h | 0d |  | must start on 2003-11-24 |  |  |
| 12 | 2 | **Payload Controller (PLC) & Subordinate Sensors** |  | 62.14d | 2003-10-27 | 2004-01-21 |  | 2003-10-27 | 2004-01-21 | 62.14d | 0d |  |  |  | 264h |
| 14 | 2.1 | MBARI's INS data feed acquisition via 7k sonar i/o module |  | 5.71h | 2003-10-27 | 2003-10-27 | 6 | 2003-10-27 | 2003-10-27 | 5.71h | 0d |  |  | WA [70%] | 4h |
| 15 | 2.2 | 7KSONAR: Completion of shared memory interface re-work |  | 22.86h | 2003-10-27 | 2003-10-30 | 14 | 2003-10-27 | 2003-10-30 | 22.86h | 0d |  |  | WA [70%] | 16h |
| 16 | 2.3 | 7K SONAR & PLC: Complete trigger controller |  | 45.72h | 2003-10-30 | 2003-11-07 | 15 | 2003-10-30 | 2003-11-07 | 45.72h | 0d |  |  | WA [70%] | 32h |
| 17 | 2.4 | 7K SONAR integration: Circular buffering and large buffering stratagy review and rework |  | 22.86h | 2003-11-07 | 2003-11-12 | 16 | 2003-11-07 | 2003-11-12 | 22.86h | 0d |  |  | WA [70%] | 16h |
| 18 | 2.5 | 3.2.14.1 7K SONAR integration: Generic PLC commands (SendCommand() etc.) |  | 11.43h | 2003-11-12 | 2003-11-13 | 17 | 2003-11-12 | 2003-11-13 | 11.43h | 0d |  |  | WA [70%] | 8h |
| 19 | 2.6 | 3.2.14.2 7K SONAR integration: Routing of non-PLC commands |  | 5.71h | 2003-11-13 | 2003-11-14 | 18 | 2003-11-13 | 2003-11-14 | 5.71h | 0d |  |  | WA [70%] | 4h |
| 20 | 2.7 | 3.2.14.3 7K SONAR integration: Records to be queried and logged at startup and file switch over |  | 11.43h | 2003-11-14 | 2003-11-24 | 19 | 2003-11-14 | 2003-11-24 | 11.43h | 0d |  |  | WA [70%] | 8h |
| 21 | 2.8 | 3.2.16.1 to .2 Time synchonization: Standalone mode, slaved mode and sync of timer to 7k time |  | 45.72h | 2003-11-24 | 2003-12-02 | 20 | 2003-11-24 | 2003-12-02 | 45.72h | 0d |  |  | WA [70%] | 32h |
| 22 | 2.9 | 7K SONAR integration: Store and restore configuration |  | 11.43h | 2003-12-02 | 2003-12-03 | 21 | 2003-12-02 | 2003-12-03 | 11.43h | 0d |  |  | WA [70%] | 8h |
| 23 | 2.10 | Testing and debugging w/ 7k simulator |  | 57.14h | 2003-12-03 | 2003-12-15 | 22 | 2003-12-03 | 2003-12-15 | 57.14h | 0d |  |  | WA [70%] | 40h |
| 24 | 2.11 | Bulk of 7k sonar interfacing complete | milestone | 0h | 2003-12-15 | 2003-12-15 | 23 | 2003-12-15 | 2003-12-15 | 0h | 0d |  |  |  |  |
| 25 | 2.12 | 3.2.15.1 to .3 Critical parameter data table: Sound speed, trigger parameters & vehicle attitude |  | 11.43h | 2003-12-15 | 2003-12-16 | 24 | 2003-12-15 | 2003-12-16 | 11.43h | 0d |  |  | WA [70%] | 8h |
| 26 | 2.13 | 3.2.22 Preprocessing of routed 7k messages prior to dispatch |  | 11.43h | 2003-12-16 | 2003-12-17 | 25 | 2003-12-16 | 2003-12-17 | 11.43h | 0d |  |  | WA [70%] | 8h |
| 27 | 2.14 | 3.2.23 EdgeTech FSDW to subscribe to critical trigger parameters |  | 5.71h | 2003-12-17 | 2003-12-18 | 26 | 2003-12-17 | 2003-12-18 | 5.71h | 0d |  |  | WA [70%] | 4h |
| 28 | 2.15 | EdgeTech SONAR integration: EdgeTech Trigger notification and range selection |  | 11.43h | 2003-12-18 | 2004-01-05 | 27 | 2003-12-18 | 2004-01-05 | 11.43h | 0d |  |  | WA [70%] | 8h |
| 29 | 2.16 | EdgeTech SONAR integration: EdgeTech to use external uncoupled triggering |  | 2.86h | 2004-01-05 | 2004-01-05 | 28 | 2004-01-05 | 2004-01-05 | 2.86h | 0d |  |  | WA [70%] | 2h |
| 30 | 2.17 | 7K SONAR integration: Rework 7k internal error handling and reporting |  | 22.86h | 2004-01-05 | 2004-01-08 | 29 | 2004-01-05 | 2004-01-08 | 22.86h | 0d |  |  | WA [70%] | 16h |
| 31 | 2.18 | 7K SONAR integration: Health and status reporting |  | 11.43h | 2004-01-08 | 2004-01-09 | 30 | 2004-01-08 | 2004-01-09 | 11.43h | 0d |  |  | WA [70%] | 8h |
| 32 | 2.19 | 3.3.7 SEL identifiers of clients and sensors etc. |  | 8.57h | 2004-01-09 | 2004-01-12 | 31 | 2004-01-09 | 2004-01-12 | 8.57h | 0d |  |  | WA [70%] | 6h |
| 33 | 2.20 | EdgeTech SONAR integration: Default state command implementation |  | 5.71h | 2004-01-12 | 2004-01-13 | 32 | 2004-01-12 | 2004-01-13 | 5.71h | 0d |  |  | WA [70%] | 4h |
| 34 | 2.21 | Sensor default state restoration |  | 22.86h | 2004-01-13 | 2004-01-16 | 33 | 2004-01-13 | 2004-01-16 | 22.86h | 0d |  |  | WA [70%] | 16h |
| 35 | 2.22 | Code completion | milestone | 0h | 2004-01-16 | 2004-01-16 | 34 | 2004-01-16 | 2004-01-16 | 0h | 0d |  |  |  |  |
| 36 | 2.23 | Testing and debugging |  | 22.86h | 2004-01-16 | 2004-01-21 | 35 | 2004-01-16 | 2004-01-21 | 22.86h | 0d |  |  | WA [70%] | 16h |
| 38 | 2.24 | End PLC Phase II Development | milestone | 0d | 2004-01-21 | 2004-01-21 | 36 | 2004-01-21 | 2004-01-21 | 0d | 0d |  |  |  |  |

| ID | WBS | Task | Type | Duration | Start | Finish | Predecessors | Baseline start | Baseline finish | Baseline duration | Total slack | Free slack | Resources | Work |
| --- | --- | --- | --- | --- | --- | --- | --- | --- | --- | --- | --- | --- | --- | --- |
| 40 | 3 | **Data Visualization Utilitiy (DVU)** |  | 25.56d | 2003-11-17 | 2003-12-22 |  | 2003-11-17 | 2003-12-22 | 25.56d | 14.59d |  |  | 184h |
| 42 | 3.1 | 2D Bathy scrolling display |  | 88.89h | 2003-11-17 | 2003-12-02 | 4 | 2003-11-17 | 2003-12-02 | 88.89h | 14.59d | 0d | JM [90%] | 80h |
| 43 | 3.2 | UI rework (compliance w/ RESON guidelines) plus waterfall improvements |  | 8.89h | 2003-12-02 | 2003-12-03 | 42 | 2003-12-02 | 2003-12-03 | 8.89h | 14.59d | 0d | JM [90%] | 8h |
| 44 | 3.3 | RESON 7k sonar trigger control panel and setup |  | 44.45h | 2003-12-03 | 2003-12-10 | 43, 16 | 2003-12-03 | 2003-12-10 | 44.45h | 14.59d | 0d | JM [90%] | 40h |
| 45 | 3.4 | RESON 7k sonar control panel |  | 17.78h | 2003-12-10 | 2003-12-12 | 44 | 2003-12-10 | 2003-12-12 | 17.78h | 21.59d | 0d | JM [90%] | 16h |
| 46 | 3.5 | Code completion | milestone | 0h | 2003-12-12 | 2003-12-12 | 45 | 2003-12-12 | 2003-12-12 | 0h | 21.59d | 0d |  |  |
| 47 | 3.6 | Testing and debugging |  | 44.45h | 2003-12-15 | 2003-12-22 | 46, 24 | 2003-12-15 | 2003-12-22 | 44.45h | 21.59d | 0d | JM [90%] | 40h |
| 49 | 3.7 | End DVU Phase II Development | milestone | 0h | 2003-12-22 | 2003-12-22 | 47 | 2003-12-22 | 2003-12-22 | 0h | 21.59d |  |  |  |
| 51 | 4 | **User Manual** |  | 16.67d | 2004-01-21 | 2004-02-12 |  | 2004-01-21 | 2004-02-12 | 16.67d | 40.12d |  |  | 68h |
| 53 | 4.1 | Preparation |  | 32h | 2004-01-21 | 2004-01-27 | 7, 38, 49 | 2004-01-21 | 2004-01-27 | 32h | 40.12d | 0d | MD [50%] | 16h |
| 54 | 4.2 | Feature completion |  | 80h | 2004-01-27 | 2004-02-10 | 53, 38, 49 | 2004-01-27 | 2004-02-10 | 80h | 40.12d | 0d | MD [50%] | 40h |
| 55 | 4.3 | Review |  | 5.33h | 2004-02-10 | 2004-02-10 | 54 | 2004-02-10 | 2004-02-10 | 5.33h | 40.12d | 0d | MF [25%]; WA [50%] | 4h |
| 56 | 4.4 | Rework |  | 16h | 2004-02-10 | 2004-02-12 | 55 | 2004-02-10 | 2004-02-12 | 16h | 40.12d | 0d | MD [50%] | 8h |
| 58 | 4.5 | User manual completed | milestone | 0h | 2004-02-12 | 2004-02-12 | 56 | 2004-02-12 | 2004-02-12 | 0h | 40.12d |  |  |  |
| 60 | 5 | **Software Testing** |  | 26.46d | 2004-01-21 | 2004-02-26 |  | 2004-01-21 | 2004-02-26 | 26.46d | 0d |  |  | 159h |
| 62 | 5.1 | Software integration testing |  | 25h | 2004-01-21 | 2004-01-26 | 49, 38 | 2004-01-21 | 2004-01-26 | 25h | 0d |  | WA [70%]; JM [90%] | 40h |
| 63 | 5.2 | SQC Fault Model Testing of PLC |  | 160h | 2004-01-26 | 2004-02-23 | 62 | 2004-01-26 | 2004-02-23 | 160h | 0.65d | 0d | MF [25%] | 40h |
| 64 | 5.3 | SQC Fault model testing of DVU |  | 160h | 2004-01-26 | 2004-02-23 | 62 | 2004-01-26 | 2004-02-23 | 160h | 0d |  | MF [25%] | 40h |
| 65 | 5.4 | Rework PLC |  | 21.43h | 2004-02-23 | 2004-02-25 | 63 | 2004-02-23 | 2004-02-25 | 21.43h | 0.65d |  | WA [70%] | 15h |
| 66 | 5.5 | Rework DVU |  | 26.67h | 2004-02-23 | 2004-02-26 | 64 | 2004-02-23 | 2004-02-26 | 26.67h | 0d |  | JM [90%] | 24h |
| 68 | 5.6 | Completion of 6046 development | milestone | 0h | 2004-02-26 | 2004-02-26 | 65, 66 | 2004-02-26 | 2004-02-26 | 0h | 0d |  |  |  |
| 70 | 6 | **System testing and field trials** |  | 28.33d | 2004-02-26 | 2004-04-06 |  | 2004-02-26 | 2004-04-06 | 28.33d | 0d |  |  | 152h |
| 72 | 6.1 | Systems integration testing & rework |  | 25h | 2004-02-26 | 2004-03-02 | 68 | 2004-02-26 | 2004-03-02 | 25h | 0d |  | WA [70%]; JM [90%] | 40h |
| 73 | 6.2 | SQC Fault Model Testing |  | 64h | 2004-03-02 | 2004-03-12 | 72 | 2004-03-02 | 2004-03-12 | 64h | 0d |  | MF [25%] | 16h |
| 74 | 6.3 | Rework |  | 15h | 2004-03-12 | 2004-03-16 | 73 | 2004-03-12 | 2004-03-16 | 15h | 0d |  | WA [70%]; JM [90%] | 24h |
| 75 | 6.4 | Formal Testing |  | 96h | 2004-03-16 | 2004-04-01 | 74 | 2004-03-16 | 2004-04-01 | 96h | 0d |  | MF [25%] | 24h |
| 76 | 6.5 | Rework |  | 5h | 2004-04-01 | 2004-04-02 | 75 | 2004-04-01 | 2004-04-02 | 5h | 0d |  | WA [70%]; JM [90%] | 8h |
| 77 | 6.6 | Sea-trials + rework |  | 21.62h | 2004-04-02 | 2004-04-06 | 76 | 2004-04-02 | 2004-04-06 | 21.62h | 0d |  | MF [25%]; WA [70%]; JM [90%] | 40h |
| 79 | 6.7 | Completion of trials | milestone | 0h | 2004-04-06 | 2004-04-06 | 77 | 2004-04-06 | 2004-04-06 | 0h | 0d |  |  |  |

| ID | WBS | Task | Type | Duration | Start | Finish | Predecessors | Baseline start | Baseline finish | Baseline duration | Total slack | Resources | Work |
| --- | --- | --- | --- | --- | --- | --- | --- | --- | --- | --- | --- | --- | --- |
| 82 | 7 | **6046 Release** |  | 2d | 2004-04-06 | 2004-04-08 |  | 2004-04-06 | 2004-04-08 | 2d | 0d |  | 4h |
| 84 | 7.1 | CD Preparation |  | 8h | 2004-04-06 | 2004-04-07 | 79 | 2004-04-06 | 2004-04-07 | 8h | 0d | MF [25%] | 2h |
| 85 | 7.2 | CD Installation testing |  | 8h | 2004-04-07 | 2004-04-08 | 84 | 2004-04-07 | 2004-04-08 | 8h | 0d | MF [25%] | 2h |
| 86 | 7.3 | Release | milestone | 0h | 2004-04-08 | 2004-04-08 | 85 | 2004-04-08 | 2004-04-08 | 0h | 0d |  |  |
| 88 | 7.4 | 6046 Phase II completion | milestone | 0h | 2004-04-08 | 2004-04-08 | 86 | 2004-04-08 | 2004-04-08 | 0h | 0d |  |  |
