# 6046 Project Schedule as of 15 Apri l04.doc

Schedule from MS Project, 2004-04-19 to 2004-10-11, A marks actual dates.

## Calendars

- Standard: Mon-Fri 08:00-12:00, 13:00-17:00; Sat-Sun off.

## Resources

| Resource |
| --- |
| JM |
| MD |
| MF |
| WA |
| LA |
| SW |

## Schedule

| ID | WBS | Task | Type | Duration | Start | Finish | Predecessors | Complete | Remaining | Total slack | Free slack | Constraint | Resources | Work | Actual work |
| --- | --- | --- | --- | --- | --- | --- | --- | --- | --- | --- | --- | --- | --- | --- | --- |
| 2 | 1 | **Misc. Preparation** |  | 0.54d | 2004-04-19 A | 2004-04-19 A |  | 100% |  |  |  |  |  | 4h | 4h |
| 3 | 1.1 | Revise PLC SRS |  | 2.22h | 2004-04-19 A | 2004-04-19 A |  | 100% |  |  |  |  | WA [90%] | 2h | 2h |
| 4 | 1.2 | Review |  | 1h | 2004-04-19 A | 2004-04-19 A | 3 | 100% |  |  |  |  | LA | 1h | 1h |
| 5 | 1.3 | Rework |  | 1.11h | 2004-04-19 A | 2004-04-19 A | 4 | 100% |  |  |  |  | WA [90%] | 1h | 1h |
| 6 | 1.4 | Release | milestone | 0h | 2004-04-19 A | 2004-04-19 A | 5 | 100% |  |  |  |  |  |  |  |
| 8 | 2 | **Payload Controller (PLC)** |  | 109.25d? | 2004-04-19 A | 2004-09-17 |  | 55% | 48.81d? | 15.33d |  |  |  | 492h | 261.61h |
| 10 | 2.1 | **General** |  | 83.62d | 2004-04-19 A | 2004-08-13 |  | 82% | 15d | 40.95d |  |  |  | 246h | 198.48h |
| 11 | 2.1.1 | v4 7k protocol compliance, support for revised 7k data center memory map layout, shared memory buffer management enhancements |  | 40h | 2004-04-19 A | 2004-04-27 A | 6 | 100% |  |  |  |  | WA [80%] | 32h | 32h |
| 12 | 2.1.2 | 7K SONAR integration: buffering strategy review and re-work |  | 10h | 2004-04-27 A | 2004-04-28 A | 11 | 100% |  |  |  |  | WA [80%] | 8h | 8h |
| 13 | 2.1.3 | 7K SONAR integration: Generic PLC commands (SendCommand() etc.) |  | 19.33h | 2004-04-28 A | 2004-08-04 | 12 | 80% | 3.87h | 47.79d |  |  | WA [90%] | 16h | 12.52h |
| 14 | 2.1.4 | 7K SONAR integration: Routing of non-PLC commands |  | 5h | 2004-04-30 A | 2004-04-30 A | 13 | 100% |  |  |  |  | WA [80%] | 4h | 4h |
| 15 | 2.1.5 | 7K SONAR integration: Records to be queried and logged at startup and file switch over |  | 10h | 2004-04-30 A | 2004-05-03 A | 14 | 100% |  |  |  |  | WA [80%] | 8h | 8h |
| 16 | 2.1.6 | Testing and debugging w/ 7k simulator |  | 100h | 2004-05-03 A | 2004-05-20 A | 15 | 100% |  |  |  |  | WA [80%] | 80h | 80h |
| 17 | 2.1.7 | Attitude collection and subscription from sonar |  | 6.83h | 2004-05-12 A | 2004-08-03 | 16 | 60% | 2.73h | 1.83d | 0d |  | WA [90%] | 6h | 3.54h |
| 18 | 2.1.8 | Time synchronization: Standalone mode, slaved mode and sync of timer to 7k time |  | 36h | 2004-05-21 A | 2004-08-03 | 17 | 90% | 3.6h | 1.83d | 0d |  | WA [90%] | 32h | 28.76h |
| 19 | 2.1.9 | 7K SONAR integration: Store and restore configuration |  | 8.89h | 2004-07-02 A | 2004-08-03 | 18 | 95% | 0.45h | 1.83d | 0d | start no earlier than 2004-06-21 | WA [90%] | 8h | 7.6h |
| 20 | 2.1.10 | 7K SONAR integration: Rework 7k internal error handling and reporting |  | 9h | 2004-06-21 A | 2004-08-05 | 19 | 20% | 7.2h | 1.34d | 0d |  | WA [90%] | 8h | 1.52h |
| 21 | 2.1.11 | 7K SONAR integration: Health and status reporting |  | 8.89h | 2004-08-05 | 2004-08-06 | 20 |  |  | 1.34d | 0d | start no earlier than 2004-07-27 | WA [90%] | 8h |  |
| 22 | 2.1.12 | Optional collection of 7k attitude data from sonar (e.g., MBARI etc) |  | 4.45h | 2004-08-06 | 2004-08-09 | 21 |  |  | 1.34d | 0d | start no earlier than 2004-07-27 | WA [90%] | 4h |  |
| 23 | 2.1.13 | Client messaging support in interface DLL etc. |  | 18h | 2004-06-18 A | 2004-08-11 | 22 | 30% | 12.6h | 0.56d | 0d |  | WA [90%] | 16h | 4.66h |
| 24 | 2.1.14 | Critical parameter data table: Sound speed, trigger parameters & vehicle attitude |  | 8.89h | 2004-07-12 A | 2004-08-12 | 23 | 50% | 4.45h | 0.22d | 0d |  | WA [90%] | 8h | 4h |
| 25 | 2.1.15 | Preprocessing of routed 7k messages prior to dispatch |  | 9.17h | 2004-06-11 A | 2004-08-13 | 24 | 50% | 4.58h | 0.22d | 0d |  | WA [90%] | 8h | 3.88h |
| 27 | 2.2 | **JAMSTEC, SBUS (AUV62) & NCSC (?) Requirements** |  | 32.01d | 2004-07-05 A | 2004-08-18 |  | 69% | 9.86d | 0d |  |  |  | 80h | 55.13h |
| 28 | 2.2.1 | New generic 7k sensor module |  | 63h | 2004-07-05 A | 2004-08-13 | 25 | 90% | 6.3h | 0.22d | 0d |  | WA [90%] | 56h | 50.33h |
| 29 | 2.2.2 | Ack/nak of routed commands to 7k sonar and command to suport non-specific addressing |  | 26.67h | 2004-08-02 A | 2004-08-18 | 28 | 20% | 21.33h | 0d |  |  | WA [90%] | 24h | 4.8h |

| ID | WBS | Task | Type | Duration | Start | Finish | Predecessors | Complete | Remaining | Total slack | Free slack | Constraint | Resources | Work | Actual work |
| --- | --- | --- | --- | --- | --- | --- | --- | --- | --- | --- | --- | --- | --- | --- | --- |
| 31 | 2.3 | **Developer Testing & Debugging** |  | 15.44d | 2004-08-05 A | 2004-08-27 |  | 10% | 13.89d | 0d |  |  |  | 48h | 4.8h |
| 32 | 2.3.1 | Correct known defects per DevTrack (issues as of 15 April 04) |  | 35.55h | 2004-08-05 A | 2004-08-24 | 29 | 15% | 30.22h | 0d |  |  | WA [90%] | 32h | 4.8h |
| 33 | 2.3.2 | General testing and debugging |  | 17.78h | 2004-08-24 | 2004-08-27 | 32 |  |  | 0d |  |  | WA [90%] | 16h |  |
| 35 | 2.4 | Completion of PLC meeting JAMSTEC(et. al.) requirements | milestone | 0h | 2004-08-27 | 2004-08-27 | 33 |  |  | 30.83d | 0d |  |  |  |  |
| 37 | 2.5 | **MBARI, Thales/Fugro Requirements** |  | 13.73d? | 2004-08-25 A | 2004-09-13 |  | 4% | 13.22d? | 1.83d |  |  |  | 86h | 3.2h |
| 38 | 2.5.1 | Trigger controller |  | 35.55h | 2004-08-25 A | 2004-09-02 | 33 | 10% | 32h | 0d |  |  | WA [90%] | 32h | 3.2h |
| 39 | 2.5.2 | EdgeTech FSDW to subscribe to critical trigger parameters |  | 4.44h | 2004-09-02 | 2004-09-02 | 38 |  |  | 1.83d | 0d |  | WA [90%] | 4h |  |
| 40 | 2.5.3 | EdgeTech SONAR integration: EdgeTech Trigger notification and range selection |  | 8.89h | 2004-09-02 | 2004-09-03 | 39 |  |  | 1.83d | 0d |  | WA [90%] | 8h |  |
| 41 | 2.5.4 | EdgeTech SONAR integration: EdgeTech to use external uncoupled triggering |  | 2.22h | 2004-09-03 | 2004-09-06 | 40 |  |  | 1.83d | 0d |  | WA [90%] | 2h |  |
| 42 | 2.5.5 | Dongle replacement once policy known |  | 44.45h? | 2004-09-06 | 2004-09-13 | 41 |  |  | 1.83d | 0d |  | WA [90%] | 40h |  |
| 44 | 2.6 | **Developer Testing & Debugging** |  | 4d | 2004-09-13 | 2004-09-17 |  |  |  | 1.83d |  |  |  | 32h |  |
| 45 | 2.6.1 | General testing and debugging |  | 32h | 2004-09-13 | 2004-09-17 | 42 |  |  | 1.83d | 0d |  | WA | 32h |  |
| 47 | 2.6.2 | Completion of PLC meeting MBARI & Thales/Fugro requirements | milestone | 0h | 2004-09-17 | 2004-09-17 | 45 |  |  | 1.83d |  |  |  |  |  |
| 49 | 3 | **Data Visualization Utility (DVU)** |  | 39.62d? | 2004-07-28 | 2004-09-21 |  |  |  | 13.5d |  |  |  | 160h |  |
| 50 | 3.1 | 2D Bathy scrolling display |  | 17.78h | 2004-08-03 | 2004-08-05 | 16 |  |  | 31.18d | 2.67d | start no earlier than 2004-08-02 | JM [90%] | 16h |  |
| 51 | 3.2 | 7k sonar control panel |  | 17.78h | 2004-08-05 | 2004-08-09 | 16 |  |  | 28.51d | 0d | start no earlier than 2004-08-02 | JM [90%] | 16h |  |
| 53 | 3.3 | Completion of DVU meeting JAMSTEC(et. al.) requirements | milestone | 0h | 2004-08-09 | 2004-08-09 | 50, 51 |  |  | 44.23d | 13.4d | start no earlier than 2004-07-27 |  |  |  |
| 55 | 3.4 | RESON 7k sonar trigger control panel and setup |  | 88.89h | 2004-09-02 | 2004-09-17 | 38 |  |  | 0d |  |  | JM [90%] | 80h |  |
| 57 | 3.5 | Code completion | milestone | 0h | 2004-09-17 | 2004-09-17 | 50, 51, 55 |  |  | 0d |  |  |  |  |  |
| 58 | 3.6 | Correct known defects per DevTrack (issues as of 15 April 04) |  | 35.55h? | 2004-07-28 | 2004-08-05 | 16 |  |  | 46.45d |  | start no earlier than 2004-07-27 | JM [90%] | 32h |  |
| 59 | 3.7 | Testing and debugging |  | 17.78h | 2004-09-17 | 2004-09-21 | 57 |  |  | 0d |  |  | JM [90%] | 16h |  |
| 61 | 3.8 | Interim version of PLC and DVU meeting JAMSTEC (et. al.) requirements | milestone | 0h | 2004-08-27 | 2004-08-27 | 35, 53 |  |  | 30.83d |  |  |  |  |  |
| 63 | 4 | End DVU Phase II Development | milestone | 0d | 2004-09-21 | 2004-09-21 | 59 |  |  | 0d |  |  |  |  |  |
| 65 | 5 | **User Manual** |  | 32.66d | 2004-08-06 | 2004-09-22 |  |  |  | 12.18d |  |  |  | 53.06h |  |
| 66 | 5.1 | Feature Completion |  | 80h | 2004-08-06 | 2004-08-20 | 21 |  |  | 12.21d | 0d | start no earlier than 2004-07-27 | MD [50%] | 40h |  |
| 67 | 5.2 | Review |  | 5.63h | 2004-09-03 | 2004-09-20 | 66 |  |  | 12.18d | 0d |  | WA [90%] | 5.06h |  |
| 68 | 5.3 | Rework |  | 16h | 2004-09-20 | 2004-09-22 | 67 |  |  | 12.18d | 0d |  | MD [50%] | 8h |  |
| 69 | 5.4 | Manual completion | milestone | 0h | 2004-09-22 | 2004-09-22 | 68 |  |  | 12.18d |  |  |  |  |  |

| ID | WBS | Task | Type | Duration | Start | Finish | Predecessors | Total slack | Constraint | Resources | Work |
| --- | --- | --- | --- | --- | --- | --- | --- | --- | --- | --- | --- |
| 71 | 6 | **Systems integration testing & rework** |  | 48.62d | 2004-08-03 | 2004-10-08 |  | 0.5d |  |  | 112h |
| 72 | 6.1 | Update STP based on revised PLC SRS |  | 8h | 2004-08-03 | 2004-08-03 | 6 | 48.12d | start no earlier than 2004-08-02 | LA | 8h |
| 73 | 6.2 | Systems integration testing & rework |  | 25h | 2004-09-21 | 2004-09-24 | 63, 47 | 0d |  | SW | 25h |
| 74 | 6.3 | SQC Fault Model Testing |  | 16h | 2004-09-24 | 2004-09-28 | 73 | 0d |  | LA | 16h |
| 75 | 6.4 | Rework |  | 15h | 2004-09-28 | 2004-09-30 | 74 | 0d |  | SW | 15h |
| 76 | 6.5 | Formal Testing |  | 24h | 2004-09-30 | 2004-10-05 | 75 | 0d |  | LA | 24h |
| 77 | 6.6 | Rework |  | 10h | 2004-10-05 | 2004-10-06 | 76 | 0d |  | SW | 10h |
| 78 | 6.7 | Sea-trials and/or tank testing |  | 14h | 2004-10-06 | 2004-10-08 | 77 | 0d |  | SW | 14h |
| 79 | 6.8 | Completion of trials | milestone | 0h | 2004-10-08 | 2004-10-08 | 78 | 0d |  |  |  |
| 81 | 7 | **6046 Release** |  | 0.5d | 2004-10-08 | 2004-10-11 |  | 0d |  |  | 4h |
| 82 | 7.1 | CD Preparation |  | 2h | 2004-10-08 | 2004-10-08 | 79, 69 | 0d |  | MF | 2h |
| 83 | 7.2 | CD Installation testing |  | 2h | 2004-10-08 | 2004-10-11 | 82 | 0d |  | MF | 2h |
| 84 | 7.3 | Release | milestone | 0h | 2004-10-11 | 2004-10-11 | 83 | 0d |  |  |  |
| 86 | 8 | Phase II project completion | milestone | 0d | 2004-10-11 | 2004-10-11 | 84 | 0d |  |  |  |
