# 6046 Project Schedule as of 15 Apri l04.doc

Schedule from MS Project, 2004-08-23 to 2004-11-01, A marks actual dates.

## Calendars

- Standard: Mon-Fri 08:00-12:00, 13:00-17:00; Sat-Sun off.

## Resources

| Resource |
| --- |
| JM |
| MD |
| MF |
| WA |
| LA |
| SW |
| SQC |

## Schedule

| ID | WBS | Task | Duration | Start | Finish | Predecessors | Complete | Remaining | Total slack | Free slack | Constraint | Resources | Work | Actual work |
| --- | --- | --- | --- | --- | --- | --- | --- | --- | --- | --- | --- | --- | --- | --- |
| 2 | 1 | **General Project** | 3d | 2004-08-23 A | 2004-08-25 |  | 86% | 0.41d | 0.89d |  |  |  | 22h | 19h |
| 3 | 1.1 | Review JAMSTEC requirements, bug lists, code status and misc. info | 10h | 2004-08-23 A | 2004-08-24 A |  | 100% |  |  |  |  | WA | 10h | 10h |
| 4 | 1.2 | Estimation and schedule rework | 4h | 2004-08-24 A | 2004-08-24 A | 3 | 100% |  |  |  |  | WA | 4h | 4h |
| 5 | 1.3 | Rework following review | 2h | 2004-08-25 A | 2004-08-25 A | 4 | 100% |  |  |  | start no earlier than 2004-08-25 | WA | 2h | 2h |
| 6 | 1.4 | DVU and PLC SRS Update | 3h | 2004-08-25 A | 2004-08-25 A | 5 | 100% |  |  |  |  | WA | 3h | 3h |
| 7 | 1.5 | Review | 1h | 2004-08-25 | 2004-08-25 | 6 |  |  | 0.89d | 0d |  | WA | 1h |  |
| 8 | 1.6 | Rework | 2h | 2004-08-25 | 2004-08-25 | 7 |  |  | 0.89d | 0d |  | WA | 2h |  |
| 10 | 2 | **Payload Controller (PLC)** | 24.38d | 2004-08-26 A | 2004-09-29 |  | 4% | 23.49d | 23.25d |  |  |  | 195h | 7.1h |
| 12 | 2.1 | **Development** | 24.38d | 2004-08-26 A | 2004-09-29 |  | 4% | 23.49d | 23.25d |  |  |  | 195h | 7.1h |
| 14 | 2.1.1 | **7k Sonar Related** | 6.25d | 2004-08-26 A | 2004-09-03 |  | 14% | 5.36d | 0d |  |  |  | 50h | 7.1h |
| 15 | 2.1.1.1 | Altitude collection and subscription from sonar | 3h | 2004-08-26 | 2004-08-26 | 8 |  |  | 0.89d | 0d |  | WA | 3h |  |
| 16 | 2.1.1.2 | 7K SONAR integration: Generic PLC commands (SendCommand() etc.) | 2h | 2004-08-26 | 2004-08-26 | 15 |  |  | 0.89d | 0d |  | WA | 2h |  |
| 17 | 2.1.1.3 | 7K SONAR integration: Store and restore configuration | 1h | 2004-08-26 | 2004-08-26 | 16 |  |  | 0.89d | 0d |  | WA | 1h |  |
| 18 | 2.1.1.4 | 7K SONAR integration: Rework 7k internal error handling and reporting | 4h | 2004-08-26 A | 2004-08-27 | 17 | 50% | 2h | 0.64d | 0d |  | WA | 4h | 2h |
| 19 | 2.1.1.5 | 7K SONAR integration: Health and status reporting | 4h | 2004-08-27 A | 2004-08-27 | 18 | 50% | 2h | 0.39d | 0d |  | WA | 4h | 2h |
| 20 | 2.1.1.6 | Optional collection of 7k attitude data from sonar (e.g., MBARI etc) | 4h | 2004-08-27 | 2004-08-30 | 19 |  |  | 0.39d | 0d |  | WA | 4h |  |
| 21 | 2.1.1.7 | Client messaging support in DLL interface etc. | 11h | 2004-08-30 A | 2004-08-31 | 20 | 10% | 9.9h | 0.25d | 0d |  | WA | 11h | 1.1h |
| 22 | 2.1.1.8 | Critical parameter subscription control mechanism | 8h | 2004-08-31 A | 2004-09-01 | 21 | 25% | 6h | 0d |  |  | WA | 8h | 2h |
| 23 | 2.1.1.9 | Critical parameter data table: Sound speed, trigger parameters & vehicle attitude | 4h | 2004-09-01 | 2004-09-02 | 22 |  |  | 0d |  |  | WA | 4h |  |
| 24 | 2.1.1.10 | Preprocessing of routed 7k messages prior to dispatch | 5h | 2004-09-02 | 2004-09-02 | 23 |  |  | 0d |  |  | WA | 5h |  |
| 25 | 2.1.1.11 | Handle remaining messages from sonar | 4h | 2004-09-02 | 2004-09-03 | 24 |  |  | 0d |  |  | WA | 4h |  |
| 27 | 2.1.2 | **Time and Synchronization** | 3.25d | 2004-09-03 | 2004-09-08 |  |  |  | 0d |  |  |  | 26h |  |
| 28 | 2.1.2.1 | Complete TimeSync DLL and test | 16h | 2004-09-03 | 2004-09-07 | 25 |  |  | 0d |  |  | WA | 16h |  |
| 29 | 2.1.2.2 | Time synchronization: Standalone mode, slaved mode and sync of timer to 7k time (using TimeSyncDLL) | 2h | 2004-09-07 | 2004-09-07 | 28 |  |  | 0d |  |  | WA | 2h |  |
| 30 | 2.1.2.3 | Slave TimeSync DLL to 7k time driver when available | 8h | 2004-09-07 | 2004-09-08 | 29 |  |  | 0d |  |  | WA | 8h |  |

Notes:
- 16: Pending input from Pam
- 17: Pending input from Pam

| ID | WBS | Task | Type | Duration | Start | Finish | Predecessors | Total slack | Free slack | Resources | Work |
| --- | --- | --- | --- | --- | --- | --- | --- | --- | --- | --- | --- |
| 32 | 2.1.3 | **JAMSTEC, SBUS (AUV62) Requirements** |  | 2.88d | 2004-09-08 | 2004-09-13 |  | 0d |  |  | 23h |
| 33 | 2.1.3.1 | TCP/IP support & enhancements |  | 16h | 2004-09-08 | 2004-09-10 | 30 | 0d |  | WA | 16h |
| 34 | 2.1.3.2 | Ack/nak of routed commands to 7k sonar and command to suport non-specific addressing |  | 7h | 2004-09-10 | 2004-09-13 | 33 | 0d |  | WA | 7h |
| 36 | 2.1.4 | **Developer Testing, Debugging, Optimization and Miscellaneous** |  | 5.75d | 2004-09-13 | 2004-09-21 |  | 0d |  |  | 46h |
| 37 | 2.1.4.1 | Investigate failure of latest 7kCenter with PLC |  | 2h | 2004-09-13 | 2004-09-13 | 34 | 0d |  | WA | 2h |
| 38 | 2.1.4.2 | Enhance network robustness in PLC interface DLL |  | 8h | 2004-09-13 | 2004-09-14 | 37 | 0d |  | WA | 8h |
| 39 | 2.1.4.3 | Correct known defects per DevTrack (issues as of 15 April 04) |  | 30h | 2004-09-14 | 2004-09-20 | 38 | 0d |  | WA | 30h |
| 40 | 2.1.4.4 | General testing and debugging |  | 6h | 2004-09-20 | 2004-09-21 | 39 | 0d |  | WA | 6h |
| 42 | 2.1.5 | **Miscellaneous** |  | 6.25d | 2004-09-21 | 2004-09-29 |  | 0d |  |  | 50h |
| 43 | 2.1.5.1 | Change default registry setting destination |  | 2h | 2004-09-21 | 2004-09-21 | 40 | 0d |  | WA | 2h |
| 44 | 2.1.5.2 | Dongle replacement (once policy known) |  | 40h | 2004-09-21 | 2004-09-28 | 43 | 0d |  | WA | 40h |
| 45 | 2.1.5.3 | Update installation script and testing |  | 4h | 2004-09-28 | 2004-09-28 | 44 | 0d |  | WA | 4h |
| 46 | 2.1.5.4 | Developer testing and debugging |  | 4h | 2004-09-28 | 2004-09-29 | 45 | 0d |  | WA | 4h |
| 48 | 2.1.6 | Completion of PLC meeting JAMSTEC requirements | milestone | 0h | 2004-09-29 | 2004-09-29 | 46 | 23.25d |  |  |  |
| 50 | 3 | **Data Visualization Utility (DVU)** |  | 23.47d | 2004-08-23 | 2004-09-23 |  | 3.9d |  |  | 169h |
| 51 | 3.1 | 2D Bathy scrolling display |  | 8.89h | 2004-08-23 | 2004-08-24 |  | 3.9d | 0d | JM [90%] | 8h |
| 52 | 3.2 | 7k sonar control panel |  | 4.45h | 2004-08-24 | 2004-08-24 | 51 | 3.9d | 0d | JM [90%] | 4h |
| 53 | 3.3 | Configuration and Real Time Settings overhaul for 7K System |  | 21.11h | 2004-08-24 | 2004-08-27 | 52 | 3.9d | 0d | JM [90%] | 19h |
| 54 | 3.4 | RESON 7k sonar trigger control panel and setup |  | 83.33h | 2004-08-27 | 2004-09-10 | 53 | 3.9d | 0d | JM [90%] | 75h |
| 55 | 3.5 | Config file handling |  | 8.89h | 2004-09-10 | 2004-09-13 | 54 | 3.9d | 0d | JM [90%] | 8h |
| 56 | 3.6 | Client synchronization issues |  | 8.89h | 2004-09-13 | 2004-09-14 | 55 | 3.9d | 0d | JM [90%] | 8h |
| 57 | 3.7 | Network Error Handling/Testing (pending Wayne's update) |  | 16.67h | 2004-09-14 | 2004-09-17 | 56, 38 | 3.9d | 0d | JM [90%] | 15h |
| 58 | 3.8 | Code completion | milestone | 0h | 2004-09-17 | 2004-09-17 | 57 | 3.9d | 0d |  |  |
| 60 | 3.9 | Correct known defects per DevTrack (issues as of 15 April 04) |  | 17.78h | 2004-09-17 | 2004-09-21 | 58 | 3.9d | 0d | JM [90%] | 16h |
| 61 | 3.10 | Testing and Debugging |  | 17.78h | 2004-09-21 | 2004-09-23 | 60 | 3.9d | 0d | JM [90%] | 16h |
| 62 | 3.11 | Interim version of PLC and DVU meeting JAMSTEC (et. al.) requirements | milestone | 0h | 2004-09-23 | 2004-09-23 | 61 | 3.9d | 0d |  |  |
| 64 | 3.12 | End DVU Phase II Development | milestone | 0h | 2004-09-23 | 2004-09-23 | 62 | 3.9d |  |  |  |

Notes:
- 43: Pending advise from Mindy

| ID | WBS | Task | Type | Duration | Start | Finish | Predecessors | Total slack | Free slack | Constraint | Resources | Work |
| --- | --- | --- | --- | --- | --- | --- | --- | --- | --- | --- | --- | --- |
| 66 | 4 | **User Manual** |  | 13.81d | 2004-09-29 | 2004-10-19 |  | 9.44d |  |  |  | 61.06h |
| 67 | 4.1 | Collect and issue technical info for manual update |  | 8.89h | 2004-09-29 | 2004-09-30 | 46 | 9.44d | 0d |  | WA [90%] | 8h |
| 68 | 4.2 | Feature Completion |  | 80h | 2004-09-30 | 2004-10-14 | 67 | 9.44d | 0d |  | MD [50%] | 40h |
| 69 | 4.3 | Review |  | 5.63h | 2004-10-14 | 2004-10-15 | 68 | 9.44d | 0d |  | WA [90%] | 5.06h |
| 70 | 4.4 | Rework |  | 16h | 2004-10-15 | 2004-10-19 | 69 | 9.44d | 0d |  | MD [50%] | 8h |
| 71 | 4.5 | Manual completion | milestone | 0h | 2004-10-19 | 2004-10-19 | 70 | 9.44d |  |  |  |  |
| 73 | 5 | **Systems integration testing & rework** |  | 15.38d | 2004-09-27 | 2004-10-18 |  | 2.38d |  |  |  | 112h |
| 74 | 5.1 | Update STP based on revised PLC SRS |  | 8h | 2004-09-27 | 2004-09-27 | 6 | 4.5d |  | start no earlier than 2004-09-27 | LA | 8h |
| 75 | 5.2 | Systems integration testing & rework |  | 25h | 2004-09-29 | 2004-10-04 | 64, 61, 46 | 0d |  |  | SW | 25h |
| 76 | 5.3 | SQC Fault Model Testing |  | 16h | 2004-10-04 | 2004-10-06 | 74, 75 | 0d |  |  | LA | 16h |
| 77 | 5.4 | Rework |  | 15h | 2004-10-06 | 2004-10-08 | 76 | 0d |  |  | SW | 15h |
| 78 | 5.5 | Formal Testing |  | 24h | 2004-10-08 | 2004-10-13 | 77 | 0d |  |  | LA | 24h |
| 79 | 5.6 | Rework |  | 10h | 2004-10-13 | 2004-10-14 | 78 | 0d |  |  | SW | 10h |
| 80 | 5.7 | Sea-trials and/or tank testing |  | 14h | 2004-10-14 | 2004-10-18 | 79 | 0d |  |  | SW | 14h |
| 81 | 5.8 | Completion of trials | milestone | 0h | 2004-10-18 | 2004-10-18 | 80 | 9.75d | 0d |  |  |  |
| 83 | 6 | **6046 Release** |  | 0.5d | 2004-10-18 | 2004-10-18 |  | 9.75d |  |  |  | 4h |
| 84 | 6.1 | CD Preparation |  | 2h | 2004-10-18 | 2004-10-18 | 81 | 9.75d | 0d |  | MF | 2h |
| 85 | 6.2 | CD Installation testing |  | 2h | 2004-10-18 | 2004-10-18 | 84 | 9.75d | 0d |  | MF | 2h |
| 86 | 6.3 | Release | milestone | 0h | 2004-10-18 | 2004-10-18 | 85 | 9.75d | 0d |  |  |  |
| 88 | 7 | Phase II project completion (JAMSTEC) | milestone | 0d | 2004-10-18 | 2004-10-18 | 86 | 9.75d |  |  |  |  |
| 90 | 8 | **MBARI, Thales/Fugro & NCSC Requirements** |  | 5.75d | 2004-10-18 | 2004-10-26 |  | 0d |  |  |  | 46h |
| 91 | 8.1 | Trigger controller |  | 28h | 2004-10-18 | 2004-10-21 | 80 | 0d |  |  | WA | 28h |
| 92 | 8.2 | EdgeTech FSDW to subscribe to critical trigger parameters |  | 4h | 2004-10-21 | 2004-10-22 | 91 | 0d |  |  | WA | 4h |
| 93 | 8.3 | EdgeTech SONAR integration: EdgeTech Trigger notification and range selection |  | 8h | 2004-10-22 | 2004-10-25 | 92 | 0d |  |  | WA | 8h |
| 94 | 8.4 | EdgeTech SONAR integration: EdgeTech to use external uncoupled triggering |  | 2h | 2004-10-25 | 2004-10-25 | 93 | 0d |  |  | WA | 2h |
| 95 | 8.5 | Developer testing |  | 4h | 2004-10-25 | 2004-10-26 | 94 | 0d |  |  | WA | 4h |

| ID | WBS | Task | Type | Duration | Start | Finish | Predecessors | Total slack | Free slack | Resources | Work |
| --- | --- | --- | --- | --- | --- | --- | --- | --- | --- | --- | --- |
| 97 | 9 | **Testing and release** |  | 3d | 2004-10-26 | 2004-10-29 |  | 0d |  |  | 24h |
| 98 | 9.1 | SQC formal testing |  | 16h | 2004-10-26 | 2004-10-28 | 95 | 0d |  | LA | 16h |
| 99 | 9.2 | Rework |  | 4h | 2004-10-28 | 2004-10-28 | 98 | 0d |  | WA | 4h |
| 100 | 9.3 | CD Preparation |  | 2h | 2004-10-28 | 2004-10-28 | 99 | 1.5d | 0d | MF | 2h |
| 101 | 9.4 | CD installation testing |  | 2h | 2004-10-28 | 2004-10-29 | 100 | 1.5d | 0d | MF | 2h |
| 103 | 10 | Phase II completion | milestone | 0h | 2004-10-29 | 2004-10-29 | 101 | 1.5d |  |  |  |
| 105 | 11 | **Miscellaneous post project** |  | 2d | 2004-10-28 | 2004-11-01 |  | 0d |  |  | 16h |
| 106 | 11.1 | Time Sync DLL Enhancements |  | 16h | 2004-10-28 | 2004-11-01 | 99 | 0d |  | WA | 16h |

Notes:
- 106: Place holder as this work is to move into the architecture project planning in due course. Break down as follows: / ·create new COM-based service framework; / ·repackage internals; and / ·create install scrip for service.
